# 67 Ulrich St

Schedule from MS Project, 2019-01-22 to 2019-05-08, costs in $.
Watsonia Software Pty Ltd

## Calendars

- Standard: Mon-Fri 08:00-12:00, 13:00-17:00; Sat-Sun off.

## Resources

| Resource | Rate |
| --- | --- |
| Draftsperson | 40 |
| Electrician | 33 |
| Plumber | 35 |
| Concreter | 18 |
| Carpenter | 19 |
| Labourer | 12 |
| Painter | 14 |
| Supervisor | 28 |
| Back Hoe & Operator | 85 |
| Cabinet Maker | 20.5 |
| Roof Tiler | 15 |
| Bricklayer | 13 |
| Plasterer | 14 |

## Schedule

| ID | WBS | Task | Type | Duration | Start | Finish | Predecessors | Total slack | Resources | Work | Cost |
| --- | --- | --- | --- | --- | --- | --- | --- | --- | --- | --- | --- |
| 1 | 1 | **Plans and Site** |  | 34d | 2019-01-22 | 2019-03-08 |  | 0d |  | 536h | 8,816 |
| 2 | 1.1 | Create Site Plans |  | 2d | 2019-01-22 | 2019-01-23 |  | 0d | Draftsperson | 16h | 640 |
| 3 | 1.2 | Arrange Council Permits |  | 2d | 2019-01-24 | 2019-01-25 | 2 | 0d | Draftsperson | 16h | 640 |
| 4 | 1.3 | Prepare Site |  | 10d | 2019-02-15 | 2019-02-28 | 3FS+14d | 0d | Labourer [300%]; Carpenter | 320h | 4,400 |
| 5 | 1.4 | Organise Materials |  | 1d | 2019-02-15 | 2019-02-15 | 4SS | 58d | Supervisor | 8h | 224 |
| 6 | 1.5 | Lay Foundations |  | 4d | 2019-03-01 | 2019-03-06 | 4 | 0d | Concreter; Carpenter; Labourer [200%] | 128h | 1,952 |
| 7 | 1.6 | Plumbing for Sewerage |  | 1d | 2019-03-07 | 2019-03-07 | 6 | 0d | Plumber | 8h | 280 |
| 8 | 1.7 | Pour Slab |  | 1d | 2019-03-08 | 2019-03-08 | 7 | 0d | Concreter [300%]; Carpenter; Labourer | 40h | 680 |
| 9 | 1.8 | Site Complete | milestone | 0d | 2019-03-08 | 2019-03-08 | 8 | 0d |  |  |  |
| 10 | 2 | **To Lock Up** |  | 22d | 2019-03-11 | 2019-04-09 | 9 | 0d |  | 672h | 9,696 |
| 11 | 2.1 | Erect Framing |  | 3d | 2019-03-11 | 2019-03-13 |  | 0d | Carpenter [400%] | 96h | 1,824 |
| 12 | 2.2 | Lay Roofing |  | 12d | 2019-03-14 | 2019-03-29 | 11 | 0d | Roof Tiler [200%]; Labourer [200%] | 384h | 5,184 |
| 13 | 2.3 | Brick Walls |  | 5d | 2019-04-01 | 2019-04-05 | 12 | 0d | Bricklayer [400%] | 160h | 2,080 |
| 14 | 2.4 | Fit Windows & Doors |  | 2d | 2019-04-08 | 2019-04-09 | 13 | 0d | Carpenter [200%] | 32h | 608 |
| 15 | 2.5 | Lockup | milestone | 0d | 2019-04-09 | 2019-04-09 | 14 | 0d |  |  |  |
| 16 | 3 | **Fit Out** |  | 21d | 2019-04-10 | 2019-05-08 | 15 | 0d |  | 440h | 8,360 |
| 17 | 3.1 | Electrical Cables |  | 1d | 2019-04-10 | 2019-04-10 |  | 0d | Electrician | 8h | 264 |
| 18 | 3.2 | Internal Plumbing |  | 2d | 2019-04-10 | 2019-04-11 | 17SS | 0d | Plumber | 16h | 560 |
| 19 | 3.3 | Plaster Walls |  | 5d | 2019-04-12 | 2019-04-18 | 18 | 0d | Plasterer [300%] | 120h | 1,680 |
| 20 | 3.4 | Internal Doors and Trim |  | 4d | 2019-04-19 | 2019-04-24 | 19 | 0d | Carpenter [200%] | 64h | 1,216 |
| 21 | 3.5 | Install Kitchen |  | 3d | 2019-04-25 | 2019-04-29 | 20 | 0d | Cabinet Maker [200%] | 48h | 984 |
| 22 | 3.6 | Install Bathroom |  | 2d | 2019-04-25 | 2019-04-26 | 21SS | 0d | Cabinet Maker; Plumber | 32h | 888 |
| 23 | 3.7 | Final Electrical Fittings |  | 2d | 2019-04-29 | 2019-04-30 | 22 | 0d | Electrician | 16h | 528 |
| 24 | 3.8 | Final Plumbing Fittings |  | 2d | 2019-04-29 | 2019-04-30 | 23SS | 0d | Plumber | 16h | 560 |
| 25 | 3.9 | Paint |  | 5d | 2019-05-01 | 2019-05-07 | 24 | 0d | Painter [300%] | 120h | 1,680 |
| 26 | 3.10 | Council Approval |  | 1d | 2019-05-08 | 2019-05-08 | 25 | 0d |  |  |  |
| 27 | 3.11 | Construction Completed | milestone | 0d | 2019-05-08 | 2019-05-08 | 26 | 0d |  |  |  |
