# 44 Smith St

Schedule from MS Project, 2019-03-19 to 2019-07-17, costs in $.
Watsonia Software Pty Ltd

## Calendars

- Standard: Mon-Fri 08:00-12:00, 13:00-17:00; Sat-Sun off.

## Resources

| Resource | Rate |
| --- | --- |
| Draftsperson | 40 |
| Electrician | 33 |
| Plumber | 35 |
| Concreter | 18 |
| Carpenter | 19 |
| Labourer | 12 |
| Painter | 14 |
| Supervisor | 28 |
| Back Hoe & Operator | 85 |
| Cabinet Maker | 20.5 |
| Roof Tiler | 15 |
| Bricklayer | 13 |
| Plasterer | 14 |

## Schedule

| ID | WBS | Task | Type | Duration | Start | Finish | Predecessors | Total slack | Resources | Work | Cost |
| --- | --- | --- | --- | --- | --- | --- | --- | --- | --- | --- | --- |
| 1 | 1 | **Plans and Site** |  | 54d | 2019-03-19 | 2019-05-31 |  | 0d |  | 1008h | 17,304 |
| 2 | 1.1 | Create Site Plans |  | 10d | 2019-03-19 | 2019-04-01 |  | 0d | Draftsperson | 80h | 3,200 |
| 3 | 1.2 | Arrange Council Permits |  | 1d | 2019-04-02 | 2019-04-02 | 2 | 0d | Draftsperson | 8h | 320 |
| 4 | 1.3 | Prepare Site |  | 12d | 2019-04-23 | 2019-05-08 | 3FS+14d | 0d | Labourer [300%]; Carpenter | 384h | 5,280 |
| 5 | 1.4 | Organise Materials |  | 1d | 2019-04-23 | 2019-04-23 | 4SS | 61d | Supervisor | 8h | 224 |
| 6 | 1.5 | Lay Foundations |  | 15d | 2019-05-09 | 2019-05-29 | 4 | 0d | Concreter; Carpenter; Labourer [200%] | 480h | 7,320 |
| 7 | 1.6 | Plumbing for Sewerage |  | 1d | 2019-05-30 | 2019-05-30 | 6 | 0d | Plumber | 8h | 280 |
| 8 | 1.7 | Pour Slab |  | 1d | 2019-05-31 | 2019-05-31 | 7 | 0d | Concreter [300%]; Carpenter; Labourer | 40h | 680 |
| 9 | 1.8 | Foundations Complete | milestone | 0d | 2019-05-31 | 2019-05-31 | 8 | 0d |  |  |  |
| 10 | 2 | **To Lock Up** |  | 13d | 2019-06-03 | 2019-06-19 |  | 0d |  | 384h | 5,808 |
| 11 | 2.1 | Erect Framing |  | 3d | 2019-06-03 | 2019-06-05 | 9 | 0d | Carpenter [400%] | 96h | 1,824 |
| 12 | 2.2 | Lay Roofing |  | 3d | 2019-06-06 | 2019-06-10 | 11 | 0d | Roof Tiler [200%]; Labourer [200%] | 96h | 1,296 |
| 13 | 2.3 | Brick Walls |  | 5d | 2019-06-11 | 2019-06-17 | 12 | 0d | Bricklayer [400%] | 160h | 2,080 |
| 14 | 2.4 | Fit Windows & Doors |  | 2d | 2019-06-18 | 2019-06-19 | 13 | 0d | Carpenter [200%] | 32h | 608 |
| 15 | 2.5 | Lockup | milestone | 0d | 2019-06-19 | 2019-06-19 | 14 | 0d |  |  |  |
| 16 | 3 | **Fit Out** |  | 20d | 2019-06-20 | 2019-07-17 |  | 0d |  | 416h | 7,752 |
| 17 | 3.1 | Electrical Cables |  | 1d | 2019-06-20 | 2019-06-20 | 15 | 0d | Electrician | 8h | 264 |
| 18 | 3.2 | Internal Plumbing |  | 1d | 2019-06-20 | 2019-06-20 | 17SS | 0d | Plumber | 8h | 280 |
| 19 | 3.3 | Plaster Walls |  | 5d | 2019-06-21 | 2019-06-27 | 18 | 0d | Plasterer [300%] | 120h | 1,680 |
| 20 | 3.4 | Internal Doors and Trim |  | 4d | 2019-06-28 | 2019-07-03 | 19 | 0d | Carpenter [200%] | 64h | 1,216 |
| 21 | 3.5 | Install Kitchen |  | 2d | 2019-07-04 | 2019-07-05 | 20 | 0d | Cabinet Maker [200%] | 32h | 656 |
| 22 | 3.6 | Install Bathroom |  | 2d | 2019-07-04 | 2019-07-05 | 21SS | 0d | Cabinet Maker; Plumber | 32h | 888 |
| 23 | 3.7 | Final Electrical Fittings |  | 2d | 2019-07-08 | 2019-07-09 | 22 | 0d | Electrician | 16h | 528 |
| 24 | 3.8 | Final Plumbing Fittings |  | 2d | 2019-07-08 | 2019-07-09 | 23SS | 0d | Plumber | 16h | 560 |
| 25 | 3.9 | Paint |  | 5d | 2019-07-10 | 2019-07-16 | 24 | 0d | Painter [300%] | 120h | 1,680 |
| 26 | 3.10 | Council Approval |  | 1d | 2019-07-17 | 2019-07-17 | 25 | 0d |  |  |  |
| 27 | 3.11 | Construction Completed | milestone | 0d | 2019-07-17 | 2019-07-17 | 26 | 0d |  |  |  |
