# 92 Ascot Park Rd

Schedule from MS Project, 2019-02-05 to 2019-06-07, costs in $.
Watsonia Software Pty Ltd

## Calendars

- Standard: Mon-Fri 08:00-12:00, 13:00-17:00; Sat-Sun off.

## Resources

| Resource | Rate |
| --- | --- |
| Draftsperson | 40 |
| Electrician | 33 |
| Plumber | 35 |
| Concreter | 18 |
| Carpenter | 19 |
| Labourer | 12 |
| Painter | 14 |
| Supervisor | 28 |
| Back Hoe & Operator | 85 |
| Cabinet Maker | 20.5 |
| Roof Tiler | 15 |
| Bricklayer | 13 |
| Plasterer | 14 |

## Schedule

| ID | WBS | Task | Type | Duration | Start | Finish | Predecessors | Total slack | Free slack | Resources | Work | Cost |
| --- | --- | --- | --- | --- | --- | --- | --- | --- | --- | --- | --- | --- |
| 1 | 1 | **Plans and Site** |  | 38d | 2019-02-05 | 2019-03-28 |  | 10d |  |  | 672h | 11,160 |
| 2 | 1.1 | Create Site Plans |  | 2d | 2019-02-05 | 2019-02-06 |  | 10d | 0d | Draftsperson | 16h | 640 |
| 3 | 1.2 | Arrange Council Permits |  | 1d | 2019-02-07 | 2019-02-07 | 2 | 10d | 0d | Draftsperson | 8h | 320 |
| 4 | 1.3 | Prepare Site |  | 5d | 2019-02-28 | 2019-03-06 | 3FS+14d | 10d | 0d | Labourer [300%]; Carpenter | 160h | 2,200 |
| 5 | 1.4 | Organise Materials |  | 1d | 2019-02-28 | 2019-02-28 | 4SS | 81d |  | Supervisor | 8h | 224 |
| 6 | 1.5 | Lay Foundations |  | 12d | 2019-03-07 | 2019-03-22 | 4 | 10d | 0d | Concreter; Carpenter; Labourer [200%] | 384h | 5,856 |
| 7 | 1.6 | Plumbing for Sewerage |  | 2d | 2019-03-25 | 2019-03-26 | 6 | 10d | 0d | Plumber | 16h | 560 |
| 8 | 1.7 | Pour Slab |  | 2d | 2019-03-27 | 2019-03-28 | 7 | 10d | 0d | Concreter [300%]; Carpenter; Labourer | 80h | 1,360 |
| 9 | 1.8 | Foundations Complete | milestone | 0d | 2019-03-28 | 2019-03-28 | 8 | 10d | 0d |  |  |  |
| 10 | 2 | **To Lock Up** |  | 21d | 2019-03-29 | 2019-04-26 | 9 | 10d |  |  | 640h | 9,152 |
| 11 | 2.1 | Erect Framing |  | 3d | 2019-03-29 | 2019-04-02 |  | 10d | 0d | Carpenter [400%] | 96h | 1,824 |
| 12 | 2.2 | Lay Roofing |  | 4d | 2019-04-03 | 2019-04-08 | 11 | 10d | 0d | Roof Tiler [200%]; Labourer [200%] | 128h | 1,728 |
| 13 | 2.3 | Brick Walls |  | 12d | 2019-04-09 | 2019-04-24 | 12 | 10d | 0d | Bricklayer [400%] | 384h | 4,992 |
| 14 | 2.4 | Fit Windows & Doors |  | 2d | 2019-04-25 | 2019-04-26 | 13 | 10d | 0d | Carpenter [200%] | 32h | 608 |
| 15 | 2.5 | Lockup | milestone | 0d | 2019-04-26 | 2019-04-26 | 14 | 10d | 0d |  |  |  |
| 16 | 3 | **Fit Out** |  | 30d | 2019-04-29 | 2019-06-07 | 15 | 10d |  |  | 640h | 11,520 |
| 17 | 3.1 | Electrical Cables |  | 2d | 2019-04-29 | 2019-04-30 |  | 10d | 0d | Electrician | 16h | 528 |
| 18 | 3.2 | Internal Plumbing |  | 2d | 2019-04-29 | 2019-04-30 | 17SS | 10d | 0d | Plumber | 16h | 560 |
| 19 | 3.3 | Plaster Walls |  | 12d | 2019-05-01 | 2019-05-16 | 18 | 10d | 0d | Plasterer [300%] | 288h | 4,032 |
| 20 | 3.4 | Internal Doors and Trim |  | 6d | 2019-05-17 | 2019-05-24 | 19 | 10d | 0d | Carpenter [200%] | 96h | 1,824 |
| 21 | 3.5 | Install Kitchen |  | 2d | 2019-05-27 | 2019-05-28 | 20 | 10d | 0d | Cabinet Maker [200%] | 32h | 656 |
| 22 | 3.6 | Install Bathroom |  | 2d | 2019-05-27 | 2019-05-28 | 21SS | 10d | 0d | Cabinet Maker; Plumber | 32h | 888 |
| 23 | 3.7 | Final Electrical Fittings |  | 3d | 2019-05-29 | 2019-05-31 | 22 | 10d | 0d | Electrician | 24h | 792 |
| 24 | 3.8 | Final Plumbing Fittings |  | 2d | 2019-05-29 | 2019-05-30 | 23SS | 10d | 0d | Plumber | 16h | 560 |
| 25 | 3.9 | Paint |  | 5d | 2019-05-31 | 2019-06-06 | 24 | 10d | 0d | Painter [300%] | 120h | 1,680 |
| 26 | 3.10 | Council Approval |  | 1d | 2019-06-07 | 2019-06-07 | 25 | 10d | 0d |  |  |  |
| 27 | 3.11 | Construction Completed | milestone | 0d | 2019-06-07 | 2019-06-07 | 26 | 10d |  |  |  |  |
