# Pool - 57 Morris Court

Schedule from MS Project, 2019-02-21 to 2019-05-10, costs in $.
Watsonia Software Pty Ltd

## Calendars

- Standard: Mon-Fri 08:00-12:00, 13:00-17:00; Sat-Sun off.

## Resources

| Resource | Rate |
| --- | --- |
| Draftsperson | 40 |
| Electrician | 33 |
| Plumber | 35 |
| Concreter | 18 |
| Carpenter | 19 |
| Labourer | 12 |
| Painter | 14 |
| Supervisor | 28 |
| Back Hoe & Operator | 85 |
| Cabinet Maker | 20.5 |
| Roof Tiler | 15 |
| Bricklayer | 13 |
| Plasterer | 14 |

## Schedule

| ID | Task | Type | Duration | Start | Finish | Predecessors | Total slack | Resources | Work | Cost |
| --- | --- | --- | --- | --- | --- | --- | --- | --- | --- | --- |
| 1 | Create Site Plans |  | 2d | 2019-02-21 | 2019-02-22 |  | 0d | Draftsperson | 16h | 640 |
| 2 | Arrange Council Permits |  | 1d | 2019-02-25 | 2019-02-25 | 1 | 0d | Draftsperson | 8h | 320 |
| 3 | Prepare Site |  | 3d | 2019-03-18 | 2019-03-20 | 2FS+14d | 0d | Labourer [300%]; Carpenter | 96h | 1,320 |
| 4 | Organise Materials |  | 1d | 2019-03-18 | 2019-03-18 | 3SS | 39d | Supervisor | 8h | 224 |
| 5 | Lay Foundations |  | 2d | 2019-03-21 | 2019-03-22 | 3 | 0d | Concreter; Carpenter; Labourer [200%] | 64h | 976 |
| 6 | Plumbing for Sewerage |  | 1d | 2019-03-25 | 2019-03-25 | 5 | 0d | Plumber | 8h | 280 |
| 7 | Pour Slab |  | 1d | 2019-03-26 | 2019-03-26 | 6 | 0d | Concreter [300%]; Carpenter; Labourer | 40h | 680 |
| 8 | Foundations Complete | milestone | 0d | 2019-03-26 | 2019-03-26 | 7 | 0d |  |  |  |
| 9 | Erect Framing |  | 3d | 2019-03-27 | 2019-03-29 | 8 | 0d | Carpenter [400%] | 96h | 1,824 |
| 10 | Lay Roofing |  | 3d | 2019-04-01 | 2019-04-03 | 9 | 0d | Roof Tiler [200%]; Labourer [200%] | 96h | 1,296 |
| 11 | Brick Walls |  | 5d | 2019-04-04 | 2019-04-10 | 10 | 0d | Bricklayer [400%] | 160h | 2,080 |
| 12 | Fit Windows & Doors |  | 2d | 2019-04-11 | 2019-04-12 | 11 | 0d | Carpenter [200%] | 32h | 608 |
| 13 | Lockup | milestone | 0d | 2019-04-12 | 2019-04-12 | 12 | 0d |  |  |  |
| 14 | Electrical Cables |  | 1d | 2019-04-15 | 2019-04-15 | 13 | 0d | Electrician | 8h | 264 |
| 15 | Internal Plumbing |  | 1d | 2019-04-15 | 2019-04-15 | 14SS | 0d | Plumber | 8h | 280 |
| 16 | Plaster Walls |  | 5d | 2019-04-16 | 2019-04-22 | 15 | 0d | Plasterer [300%] | 120h | 1,680 |
| 17 | Internal Doors and Trim |  | 4d | 2019-04-23 | 2019-04-26 | 16 | 0d | Carpenter [200%] | 64h | 1,216 |
| 18 | Install Kitchen |  | 2d | 2019-04-29 | 2019-04-30 | 17 | 0d | Cabinet Maker [200%] | 32h | 656 |
| 19 | Install Bathroom |  | 2d | 2019-04-29 | 2019-04-30 | 18SS | 0d | Cabinet Maker; Plumber | 32h | 888 |
| 20 | Final Electrical Fittings |  | 2d | 2019-05-01 | 2019-05-02 | 19 | 0d | Electrician | 16h | 528 |
| 21 | Final Plumbing Fittings |  | 2d | 2019-05-01 | 2019-05-02 | 20SS | 0d | Plumber | 16h | 560 |
| 22 | Paint |  | 5d | 2019-05-03 | 2019-05-09 | 21 | 0d | Painter [300%] | 120h | 1,680 |
| 23 | Council Approval |  | 1d | 2019-05-10 | 2019-05-10 | 22 | 0d |  |  |  |
| 24 | Construction Completed | milestone | 0d | 2019-05-10 | 2019-05-10 | 23 | 0d |  |  |  |
