# Pool - 456 Ashwood Street

Schedule from MS Project, 2019-05-16 to 2019-08-01.
Watsonia Software Pty Ltd

## Calendars

- Standard: Mon-Fri 08:00-12:00, 13:00-17:00; Sat-Sun off.

## Schedule

| ID | Task | Duration | Start | Finish | Predecessors | Total slack |
| --- | --- | --- | --- | --- | --- | --- |
| 1 | Create Site Plans | 2d | 2019-05-16 | 2019-05-17 |  | 0d |
| 2 | Arrange Council Permits | 1d | 2019-05-20 | 2019-05-20 | 1 | 0d |
| 3 | Prepare Site | 3d | 2019-06-10 | 2019-06-12 | 2FS+14d | 0d |
| 4 | Organise Materials | 1d | 2019-06-10 | 2019-06-10 | 3SS | 38d |
| 5 | Lay Foundations | 2d | 2019-06-13 | 2019-06-14 | 3 | 0d |
| 6 | Plumbing for Sewerage | 1d | 2019-06-17 | 2019-06-17 | 5 | 0d |
| 7 | Pour Slab | 1d | 2019-06-18 | 2019-06-18 | 6 | 0d |
| 8 | Erect Framing | 3d | 2019-06-19 | 2019-06-21 | 7 | 0d |
| 9 | Lay Roofing | 3d | 2019-06-24 | 2019-06-26 | 8 | 0d |
| 10 | Brick Walls | 5d | 2019-06-27 | 2019-07-03 | 9 | 0d |
| 11 | Fit Windows & Doors | 2d | 2019-07-04 | 2019-07-05 | 10 | 0d |
| 12 | Electrical Cables | 1d | 2019-07-08 | 2019-07-08 | 11 | 0d |
| 13 | Internal Plumbing | 1d | 2019-07-08 | 2019-07-08 | 12SS | 0d |
| 14 | Plaster Walls | 5d | 2019-07-09 | 2019-07-15 | 13 | 0d |
| 15 | Internal Doors and Trim | 4d | 2019-07-16 | 2019-07-19 | 14 | 0d |
| 16 | Install Kitchen | 2d | 2019-07-22 | 2019-07-23 | 15 | 0d |
| 17 | Install Bathroom | 2d | 2019-07-22 | 2019-07-23 | 16SS | 0d |
| 18 | Final Electrical Fittings | 2d | 2019-07-24 | 2019-07-25 | 17 | 0d |
| 19 | Final Plumbing Fittings | 2d | 2019-07-24 | 2019-07-25 | 18SS | 0d |
| 20 | Paint | 5d | 2019-07-26 | 2019-08-01 | 19 | 0d |
