# Tables_1

Schedule from MS Project, 2019-08-27 to 2019-09-09, costs in $.
Watsonia Software Pty Ltd

## Calendars

- Standard: Mon-Fri 08:00-12:00, 13:00-17:00; Sat-Sun off.

## Resources

| Resource | Group | Rate | Cost per use |
| --- | --- | --- | --- |
| Tony Peters | Staff | 34 |  |
| Bill May | Staff | 34 |  |
| Glenda Jacobs | Staff | 36 |  |
| Mary Smith | Staff | 54 |  |
| Sally Howard | Staff | 25 |  |
| Fred Bloggs | Staff | 24 |  |
| Ace Hire | Contractor |  | 120 |
| Stand Furniture | Hire Equipment |  | 650 |
| JustInTime Print | Printing |  | 2350 |

## Schedule

| ID | Task | Duration | Start | Finish | Predecessors | Total slack | Free slack | Resources | Work | Cost |
| --- | --- | --- | --- | --- | --- | --- | --- | --- | --- | --- |
| 1 | Design Stand Layout | 3d | 2019-08-27 08:00 | 2019-08-29 17:00 |  | 0d |  | Bill May | 24h | 816 |
| 2 | Order Furniture | 2h | 2019-08-30 08:00 | 2019-08-30 10:00 | 1 | 0d |  | Mary Smith | 2h | 108 |
| 3 | Order Supplies | 2h | 2019-08-30 10:00 | 2019-08-30 12:00 | 2 | 0d |  | Mary Smith | 2h | 108 |
| 4 | OrderLiterature | 1d | 2019-08-30 13:00 | 2019-09-02 12:00 | 3 | 0d |  | Bill May; JustInTime Print | 16h | 2,622 |
| 5 | Staff Briefing | 6h | 2019-08-27 08:00 | 2019-08-30 11:00 |  | 5.88d | 0d | Tony Peters; Bill May; Glenda Jacobs; Mary Smith; Sally Howard; Fred Bloggs | 18h | 621 |
| 6 | Issue Passes | 1h | 2019-08-30 11:00 | 2019-08-30 12:00 | 5 | 5.88d |  | Tony Peters | 1h | 34 |
| 7 | Move In | 2h | 2019-09-02 13:00 | 2019-09-02 15:00 | 4 | 0d |  | Bill May; Ace Hire | 4h | 188 |
| 8 | Exhibition | 4d | 2019-09-02 15:00 | 2019-09-06 15:00 | 7 | 0d |  | Tony Peters; Bill May; Glenda Jacobs; Mary Smith; Sally Howard; Fred Bloggs; Stand Furniture | 224h | 7,274 |
| 9 | Move Out | 2h | 2019-09-06 15:00 | 2019-09-06 17:00 | 8 | 0d |  | Bill May; Ace Hire | 4h | 188 |
| 10 | Debrief | 3h | 2019-09-09 08:00 | 2019-09-09 11:00 | 9 | 0d |  | Tony Peters; Bill May; Glenda Jacobs; Mary Smith; Sally Howard; Fred Bloggs | 18h | 621 |
